# CRONOGRAMA LINA

Schedule from MS Project, 2021-08-06 to 2022-02-10, status date 2021-08-06, costs in $.

## Calendars

- Estándar: Mon-Fri 09:00-13:00, 15:00-19:00; Sat-Sun off.

## Resources

| Resource | Group | Rate |
| --- | --- | --- |
| Gerente General (Arquitecta) | Mano de Obra | 13951 |
| Maestro de Obra | Mano de Obra | 8789 |
| Ayudante de Obra | Mano de Obra | 5455 |
| Administrador | Mano de Obra | 9622 |
| Gestor de Calidad | Mano de Obra | 9622 |
| Abogado | Mano de Obra | 9622 |

## Schedule

| ID | WBS | Task | Type | Duration | Start | Finish | Predecessors | Baseline start | Baseline finish | Baseline duration | Total slack | Resources | Work | Cost | Baseline cost |
| --- | --- | --- | --- | --- | --- | --- | --- | --- | --- | --- | --- | --- | --- | --- | --- |
| 1 | 0 | **Diseño del Servicio del Mantenimiento Locativo en la Vivienda** |  | 135d | 2021-08-06 | 2022-02-10 |  | 2021-08-06 | 2022-02-10 | 135d | 0d |  | 2232h | 27,401,824 | 27,401,824 |
| 2 | 1 | **Diagnóstico** |  | 96d | 2021-08-06 | 2021-12-17 |  | 2021-08-06 | 2021-12-17 | 96d | 0d |  | 784h | 10,834,344 | 10,834,344 |
| 3 | 1.1 | **Análisis** |  | 64d | 2021-08-06 | 2021-11-03 |  | 2021-08-06 | 2021-11-03 | 64d | 0d |  | 704h | 9,821,504 | 9,821,504 |
| 4 | 1.1.1 | **Estudio de Mercado** |  | 16d | 2021-08-06 | 2021-08-27 |  | 2021-08-06 | 2021-08-27 | 16d | 0d |  | 176h | 2,455,376 | 2,455,376 |
| 5 | 1.1.1.1 | Definir el objetivo del Estudio de Mercado |  | 5d | 2021-08-06 | 2021-08-12 |  | 2021-08-06 | 2021-08-12 | 5d | 0d | Gerente General (Arquitecta) | 40h | 558,040 | 558,040 |
| 6 | 1.1.1.2 | Recolectar la información del Estudio de Mercado |  | 8d | 2021-08-13 | 2021-08-24 | 5 | 2021-08-13 | 2021-08-24 | 8d | 0d | Gerente General (Arquitecta) | 64h | 892,864 | 892,864 |
| 7 | 1.1.1.3 | Registrar la información del Estudio de Mercado |  | 3d | 2021-08-13 | 2021-08-17 | 5 | 2021-08-13 | 2021-08-17 | 3d | 5d | Gerente General (Arquitecta) | 24h | 334,824 | 334,824 |
| 8 | 1.1.1.4 | Analizar la información del Estudio de Mercado |  | 3d | 2021-08-13 | 2021-08-17 | 5 | 2021-08-13 | 2021-08-17 | 3d | 5d | Gerente General (Arquitecta) | 24h | 334,824 | 334,824 |
| 9 | 1.1.1.5 | Sacar las conclusiones de la información del Estudio de Mercado |  | 3d | 2021-08-25 | 2021-08-27 | 8, 6, 7 | 2021-08-25 | 2021-08-27 | 3d | 0d | Gerente General (Arquitecta) | 24h | 334,824 | 334,824 |
| 10 | 1.1.2 | **Estudio Técnico** |  | 16d | 2021-08-30 | 2021-09-20 |  | 2021-08-30 | 2021-09-20 | 16d | 0d |  | 176h | 2,455,376 | 2,455,376 |
| 11 | 1.1.2.1 | Definir el objetivo del Estudio Técnico |  | 5d | 2021-08-30 | 2021-09-03 | 9 | 2021-08-30 | 2021-09-03 | 5d | 0d | Gerente General (Arquitecta) | 40h | 558,040 | 558,040 |
| 12 | 1.1.2.2 | Recolectar la información del Estudio Técnico |  | 8d | 2021-09-06 | 2021-09-15 | 11 | 2021-09-06 | 2021-09-15 | 8d | 0d | Gerente General (Arquitecta) | 64h | 892,864 | 892,864 |
| 13 | 1.1.2.3 | Registrar la información del Estudio Técnico |  | 3d | 2021-09-06 | 2021-09-08 | 11 | 2021-09-06 | 2021-09-08 | 3d | 5d | Gerente General (Arquitecta) | 24h | 334,824 | 334,824 |
| 14 | 1.1.2.4 | Analizar la información del Estudio Técnico |  | 3d | 2021-09-06 | 2021-09-08 | 11 | 2021-09-06 | 2021-09-08 | 3d | 5d | Gerente General (Arquitecta) | 24h | 334,824 | 334,824 |
| 15 | 1.1.2.5 | Sacar las conclusiones de la información del Estudio Técnico |  | 3d | 2021-09-16 | 2021-09-20 | 14, 12, 13 | 2021-09-16 | 2021-09-20 | 3d | 0d | Gerente General (Arquitecta) | 24h | 334,824 | 334,824 |
| 16 | 1.1.3 | **Estudio Financiero** |  | 16d | 2021-09-21 | 2021-10-12 |  | 2021-09-21 | 2021-10-12 | 16d | 0d |  | 176h | 2,455,376 | 2,455,376 |
| 17 | 1.1.3.1 | Definir el objetivo del Estudio Financiero |  | 5d | 2021-09-21 | 2021-09-27 | 15 | 2021-09-21 | 2021-09-27 | 5d | 0d | Gerente General (Arquitecta) | 40h | 558,040 | 558,040 |
| 18 | 1.1.3.2 | Recolectar la información del Estudio Financiero |  | 8d | 2021-09-28 | 2021-10-07 | 17 | 2021-09-28 | 2021-10-07 | 8d | 0d | Gerente General (Arquitecta) | 64h | 892,864 | 892,864 |
| 19 | 1.1.3.3 | Registrar la información del Estudio Financiero |  | 3d | 2021-09-28 | 2021-09-30 | 17 | 2021-09-28 | 2021-09-30 | 3d | 5d | Gerente General (Arquitecta) | 24h | 334,824 | 334,824 |
| 20 | 1.1.3.4 | Analizar la información del Estudio Financiero |  | 3d | 2021-09-28 | 2021-09-30 | 17 | 2021-09-28 | 2021-09-30 | 3d | 5d | Gerente General (Arquitecta) | 24h | 334,824 | 334,824 |
| 21 | 1.1.3.5 | Sacar las conclusiones de la información del Estudio Financiero |  | 3d | 2021-10-08 | 2021-10-12 | 20, 18, 19 | 2021-10-08 | 2021-10-12 | 3d | 0d | Gerente General (Arquitecta) | 24h | 334,824 | 334,824 |
| 22 | 1.1.4 | **Estudio Social y Ambiental** |  | 16d | 2021-10-13 | 2021-11-03 |  | 2021-10-13 | 2021-11-03 | 16d | 0d |  | 176h | 2,455,376 | 2,455,376 |
| 23 | 1.1.4.1 | Definir el objetivo del Estudio Social y Ambiental |  | 5d | 2021-10-13 | 2021-10-19 | 21 | 2021-10-13 | 2021-10-19 | 5d | 0d | Gerente General (Arquitecta) | 40h | 558,040 | 558,040 |
| 24 | 1.1.4.2 | Recolectar la información del Estudio Social y Ambiental |  | 8d | 2021-10-20 | 2021-10-29 | 23 | 2021-10-20 | 2021-10-29 | 8d | 0d | Gerente General (Arquitecta) | 64h | 892,864 | 892,864 |
| 25 | 1.1.4.3 | Registrar la información del Estudio Social y Ambiental |  | 3d | 2021-10-20 | 2021-10-22 | 23 | 2021-10-20 | 2021-10-22 | 3d | 5d | Gerente General (Arquitecta) | 24h | 334,824 | 334,824 |
| 26 | 1.1.4.4 | Analizar la información del Estudio Social y Ambiental |  | 3d | 2021-10-20 | 2021-10-22 | 23 | 2021-10-20 | 2021-10-22 | 3d | 79d | Gerente General (Arquitecta) | 24h | 334,824 | 334,824 |
| 27 | 1.1.4.5 | Sacar las conclusiones de la información del Estudio Social y Ambiental |  | 3d | 2021-11-01 | 2021-11-03 | 23, 24, 25 | 2021-11-01 | 2021-11-03 | 3d | 0d | Gerente General (Arquitecta) | 24h | 334,824 | 334,824 |
| 28 | HITO 1 | Entregable de Análisis Finalizada | milestone | 0d | 2021-11-03 | 2021-11-03 | 9, 15, 21, 27 | 2021-11-03 | 2021-11-03 | 0d | 71d |  |  |  |  |

| ID | WBS | Task | Type | Duration | Start | Finish | Predecessors | Baseline start | Baseline finish | Baseline duration | Total slack | Resources | Work | Cost | Baseline cost |
| --- | --- | --- | --- | --- | --- | --- | --- | --- | --- | --- | --- | --- | --- | --- | --- |
| 29 | 1.2 | **Necesidades de la vivienda** |  | 32d | 2021-11-04 | 2021-12-17 |  | 2021-11-04 | 2021-12-17 | 32d | 25d |  | 80h | 1,012,840 | 1,012,840 |
| 30 | 1.2.1 | **Listas de Chequeo** |  | 2d | 2021-11-04 | 2021-11-05 |  | 2021-11-04 | 2021-11-05 | 2d | 69d |  | 24h | 314,176 | 314,176 |
| 31 | 1.2.1.1 | Especificar los Artefactos para realizar los registros |  | 2d | 2021-11-04 | 2021-11-05 | 9, 15, 21, 27 | 2021-11-04 | 2021-11-05 | 2d | 69d | Gerente General (Arquitecta) | 16h | 223,216 | 223,216 |
| 32 | 1.2.1.2 | Diligenciar las listas de chequeo |  | 1d | 2021-11-04 | 2021-11-04 | 9, 15, 21, 27 | 2021-11-04 | 2021-11-04 | 1d | 70d | Gerente General (Arquitecta) [50%]; Maestro de Obra [50%] | 8h | 90,960 | 90,960 |
| 33 | 1.2.2 | **Informe del Estado Actual** |  | 4d | 2021-12-09 | 2021-12-14 |  | 2021-12-09 | 2021-12-14 | 4d | 0d |  | 32h | 363,840 | 363,840 |
| 34 | 1.2.2.1 | Analizar los registros en las listas de chequeo |  | 2d | 2021-12-09 | 2021-12-10 | 129, 137, 143, 150, 156, 167, 171, 177, 183 | 2021-12-09 | 2021-12-10 | 2d | 0d | Gerente General (Arquitecta) [50%]; Maestro de Obra [50%] | 16h | 181,920 | 181,920 |
| 35 | 1.2.2.2 | Sacar conclusiones de los hallazgos con las listas de chequeo |  | 2d | 2021-12-13 | 2021-12-14 | 34 | 2021-12-13 | 2021-12-14 | 2d | 0d | Gerente General (Arquitecta) [50%]; Maestro de Obra [50%] | 16h | 181,920 | 181,920 |
| 36 | 1.2.3 | **Propuesta de Trabajo** |  | 3d | 2021-12-15 | 2021-12-17 |  | 2021-12-15 | 2021-12-17 | 3d | 0d |  | 24h | 334,824 | 334,824 |
| 37 | 1.2.3.1 | Elaborar especificaciones de la metodología de trabajo |  | 2d | 2021-12-15 | 2021-12-16 | 35 | 2021-12-15 | 2021-12-16 | 2d | 0d | Gerente General (Arquitecta) | 16h | 223,216 | 223,216 |
| 38 | 1.2.3.2 | Presentar propuesta de trabajo con base en los hallazgos |  | 1d | 2021-12-17 | 2021-12-17 | 37 | 2021-12-17 | 2021-12-17 | 1d | 0d | Gerente General (Arquitecta) | 8h | 111,608 | 111,608 |
| 39 | HITO 2 | Entregable de las Necesidades de la vivienda Finalizada | milestone | 0d | 2021-12-17 | 2021-12-17 | 38 | 2021-12-17 | 2021-12-17 | 0d | 39d |  |  |  |  |
| 40 | 2 | **Diseño** |  | 3d | 2021-12-20 | 2021-12-22 |  | 2021-12-20 | 2021-12-22 | 3d | 0d |  | 108h | 1,196,988 | 1,196,988 |
| 41 | 2.1 | **Plan de Trabajo** |  | 3d | 2021-12-20 | 2021-12-22 |  | 2021-12-20 | 2021-12-22 | 3d | 0d |  | 108h | 1,196,988 | 1,196,988 |
| 42 | 2.1.1 | **Plan de Mantenimiento Eléctrico** |  | 3d | 2021-12-20 | 2021-12-22 |  | 2021-12-20 | 2021-12-22 | 3d | 0d |  | 24h | 272,880 | 272,880 |
| 43 | 2.1.1.1 | Establecer Plan de Mantenimiento Eléctrico |  | 3d | 2021-12-20 | 2021-12-22 | 38 | 2021-12-20 | 2021-12-22 | 3d | 0d | Gerente General (Arquitecta) [50%]; Maestro de Obra [50%] | 24h | 272,880 | 272,880 |
| 44 | 2.1.2 | **Plan de Mantenimiento Obra Civil** |  | 3d | 2021-12-20 | 2021-12-22 |  | 2021-12-20 | 2021-12-22 | 3d | 0d |  | 24h | 272,880 | 272,880 |
| 45 | 2.1.2.1 | Establecer Plan de Mantenimiento Obra Civil |  | 3d | 2021-12-20 | 2021-12-22 | 38 | 2021-12-20 | 2021-12-22 | 3d | 0d | Gerente General (Arquitecta) [50%]; Maestro de Obra [50%] | 24h | 272,880 | 272,880 |
| 46 | 2.1.3 | **Plan de Mantenimiento Techos, Muros y Pisos** |  | 3d | 2021-12-20 | 2021-12-22 |  | 2021-12-20 | 2021-12-22 | 3d | 0d |  | 24h | 272,880 | 272,880 |
| 47 | 2.1.3.1 | Establecer Plan de Mantenimiento Techos, Muros y Pisos |  | 3d | 2021-12-20 | 2021-12-22 | 38 | 2021-12-20 | 2021-12-22 | 3d | 0d | Gerente General (Arquitecta) [50%]; Maestro de Obra [50%] | 24h | 272,880 | 272,880 |
| 48 | 2.1.4 | **Plan de Mantenimiento Areas Comunes** |  | 3d | 2021-12-20 | 2021-12-22 |  | 2021-12-20 | 2021-12-22 | 3d | 0d |  | 36h | 378,348 | 378,348 |
| 49 | 2.1.4.1 | Establecer Plan de Mantenimiento Areas Comunes |  | 3d | 2021-12-20 | 2021-12-22 | 38 | 2021-12-20 | 2021-12-22 | 3d | 0d | Gerente General (Arquitecta) [50%]; Maestro de Obra | 36h | 378,348 | 378,348 |
| 50 | HITO 5 | Entregable del plan de trabajo finalizado | milestone | 0d | 2021-12-22 | 2021-12-22 | 43, 45, 47, 49 | 2021-12-22 | 2021-12-22 | 0d | 36d |  |  |  |  |
| 51 | 3 | **Aprobación del Trabajo** |  | 7d | 2021-12-23 | 2021-12-31 |  | 2021-12-23 | 2021-12-31 | 7d | 0d |  | 144h | 1,662,624 | 1,662,624 |
| 52 | 3.1 | **Plan de Acción** |  | 4d | 2021-12-23 | 2021-12-28 |  | 2021-12-23 | 2021-12-28 | 4d | 0d |  | 96h | 1,200,768 | 1,200,768 |
| 53 | 3.1.1 | **Informe propuesta técnica** |  | 4d | 2021-12-23 | 2021-12-28 |  | 2021-12-23 | 2021-12-28 | 4d | 0d |  | 16h | 223,216 | 223,216 |
| 54 | 3.1.1.1 | Definir planes aprobados para presentar propuesta técnica |  | 2d | 2021-12-23 | 2021-12-24 | 43, 45, 47, 49 | 2021-12-23 | 2021-12-24 | 2d | 0d | Gerente General (Arquitecta) [50%] | 8h | 111,608 | 111,608 |
| 55 | 3.1.1.2 | Redactar la información de forma clara y precisa |  | 2d | 2021-12-27 | 2021-12-28 | 54 | 2021-12-27 | 2021-12-28 | 2d | 0d | Gerente General (Arquitecta) [50%] | 8h | 111,608 | 111,608 |

| ID | WBS | Task | Type | Duration | Start | Finish | Predecessors | Baseline start | Baseline finish | Baseline duration | Total slack | Resources | Work | Cost | Baseline cost |
| --- | --- | --- | --- | --- | --- | --- | --- | --- | --- | --- | --- | --- | --- | --- | --- |
| 56 | 3.1.2 | **Informe propuesta económica** |  | 4d | 2021-12-23 | 2021-12-28 |  | 2021-12-23 | 2021-12-28 | 4d | 0d |  | 16h | 223,216 | 223,216 |
| 57 | 3.1.2.1 | Definir planes aprobados para presentar propuesta económica |  | 2d | 2021-12-23 | 2021-12-24 | 43, 45, 47, 49 | 2021-12-23 | 2021-12-24 | 2d | 0d | Gerente General (Arquitecta) [50%] | 8h | 111,608 | 111,608 |
| 58 | 3.1.2.2 | Redactar la información de forma clara y precisa |  | 2d | 2021-12-27 | 2021-12-28 | 57 | 2021-12-27 | 2021-12-28 | 2d | 0d | Gerente General (Arquitecta) [50%] | 8h | 111,608 | 111,608 |
| 59 | 3.1.3 | **Informe Acciones Correctivas** |  | 4d | 2021-12-23 | 2021-12-28 |  | 2021-12-23 | 2021-12-28 | 4d | 0d |  | 32h | 377,168 | 377,168 |
| 60 | 3.1.3.1 | Definir planes aprobados para presentar propuesta de Acciones Correctivas |  | 2d | 2021-12-23 | 2021-12-24 | 43, 45, 47, 49 | 2021-12-23 | 2021-12-24 | 2d | 0d | Gerente General (Arquitecta) [50%]; Gestor de Calidad | 24h | 265,560 | 265,560 |
| 61 | 3.1.3.2 | Redactar la información de forma clara y precisa |  | 2d | 2021-12-27 | 2021-12-28 | 60 | 2021-12-27 | 2021-12-28 | 2d | 0d | Gerente General (Arquitecta) [50%] | 8h | 111,608 | 111,608 |
| 62 | 3.1.4 | **Informe Acciones Preventivas** |  | 4d | 2021-12-23 | 2021-12-28 |  | 2021-12-23 | 2021-12-28 | 4d | 0d |  | 32h | 377,168 | 377,168 |
| 63 | 3.1.4.1 | Definir planes aprobados para presentar propuesta de Acciones Preventivas |  | 2d | 2021-12-23 | 2021-12-24 | 43, 45, 47, 49 | 2021-12-23 | 2021-12-24 | 2d | 0d | Gerente General (Arquitecta) [50%]; Gestor de Calidad | 24h | 265,560 | 265,560 |
| 64 | 3.1.4.2 | Redactar la información de forma clara y precisa |  | 2d | 2021-12-27 | 2021-12-28 | 63 | 2021-12-27 | 2021-12-28 | 2d | 0d | Gerente General (Arquitecta) [50%] | 8h | 111,608 | 111,608 |
| 65 | HITO 6 | Entregable Plan de Acción Finalizada | milestone | 0d | 2021-12-28 | 2021-12-28 | 55, 58, 61, 64 | 2021-12-28 | 2021-12-28 | 0d | 32d |  |  |  |  |
| 66 | 3.2 | **Area Legal** |  | 3d | 2021-12-29 | 2021-12-31 |  | 2021-12-29 | 2021-12-31 | 3d | 0d |  | 48h | 461,856 | 461,856 |
| 67 | 3.2.1 | **Actividades Jurídicas** |  | 3d | 2021-12-29 | 2021-12-31 |  | 2021-12-29 | 2021-12-31 | 3d | 0d |  | 48h | 461,856 | 461,856 |
| 68 | 3.2.1.1 | Realizar los contratos pertinentes de acuerdo con la relación con el proyecto |  | 3d | 2021-12-29 | 2021-12-31 | 55, 58, 61, 64 | 2021-12-29 | 2021-12-31 | 3d | 0d | Abogado; Administrador | 48h | 461,856 | 461,856 |
| 69 | HITO 7 | Entregable del Area Legal Finalizada | milestone | 0d | 2021-12-31 | 2021-12-31 | 68 | 2021-12-31 | 2021-12-31 | 0d | 29d |  |  |  |  |
| 70 | 4 | **Ejecución del Servicio** |  | 3d | 2022-01-03 | 2022-01-05 |  | 2022-01-03 | 2022-01-05 | 3d | 0d |  | 100h | 1,008,796 | 1,008,796 |
| 71 | 4.1 | **Organizar** |  | 1d | 2022-01-03 | 2022-01-03 |  | 2022-01-03 | 2022-01-03 | 1d | 0d |  | 16h | 140,624 | 140,624 |
| 72 | 4.1.1 | **Asignación de Recurso Humano** |  | 1d | 2022-01-03 | 2022-01-03 |  | 2022-01-03 | 2022-01-03 | 1d | 0d |  | 8h | 70,312 | 70,312 |
| 73 | 4.1.1.1 | Asignar Recurso Humano |  | 1d | 2022-01-03 | 2022-01-03 | 68 | 2022-01-03 | 2022-01-03 | 1d | 0d | Maestro de Obra | 8h | 70,312 | 70,312 |
| 74 | 4.1.2 | **Asignación de Herramientas y materiales** |  | 1d | 2022-01-03 | 2022-01-03 |  | 2022-01-03 | 2022-01-03 | 1d | 0d |  | 8h | 70,312 | 70,312 |
| 75 | 4.1.2.1 | Asignar Herramientas y materiales |  | 1d | 2022-01-03 | 2022-01-03 | 68 | 2022-01-03 | 2022-01-03 | 1d | 0d | Maestro de Obra | 8h | 70,312 | 70,312 |
| 76 | HITO 8 | Entregable Organizar Finalizada | milestone | 0d | 2022-01-03 | 2022-01-03 | 73, 75 | 2022-01-03 | 2022-01-03 | 0d | 28d |  |  |  |  |
| 77 | 4.2 | **Puesta en Marcha** |  | 2d | 2022-01-04 | 2022-01-05 |  | 2022-01-04 | 2022-01-05 | 2d | 0d |  | 84h | 868,172 | 868,172 |
| 78 | 4.2.1 | **Acta de inicio de Actividades** |  | 1d | 2022-01-04 | 2022-01-04 |  | 2022-01-04 | 2022-01-04 | 1d | 0d |  | 28h | 280,068 | 280,068 |
| 79 | 4.2.1.1 | Elaborar Acta de Inicio |  | 1d | 2022-01-04 | 2022-01-04 | 73, 75 | 2022-01-04 | 2022-01-04 | 1d | 0d | Gerente General (Arquitecta) [50%]; Maestro de Obra; Administrador; Abogado | 28h | 280,068 | 280,068 |

| ID | WBS | Task | Type | Duration | Start | Finish | Predecessors | Baseline start | Baseline finish | Baseline duration | Total slack | Free slack | Resources | Work | Cost | Baseline cost |
| --- | --- | --- | --- | --- | --- | --- | --- | --- | --- | --- | --- | --- | --- | --- | --- | --- |
| 80 | 4.2.2 | **Cronograma de Actividades** |  | 1d | 2022-01-05 | 2022-01-05 |  | 2022-01-05 | 2022-01-05 | 1d | 0d |  |  | 56h | 588,104 | 588,104 |
| 81 | 4.2.2.1 | Establecer plan de trabajo con base en cronograma |  | 1d | 2022-01-05 | 2022-01-05 | 79 | 2022-01-05 | 2022-01-05 | 1d | 8d | 0d | Gerente General (Arquitecta) [50%]; Maestro de Obra | 12h | 126,116 | 126,116 |
| 82 | 4.2.2.2 | Asignar tareas al recurso humano |  | 1d | 2022-01-05 | 2022-01-05 | 79 | 2022-01-05 | 2022-01-05 | 1d | 10d | 0d | Gerente General (Arquitecta) [50%]; Maestro de Obra | 12h | 126,116 | 126,116 |
| 83 | 4.2.2.3 | Realizar reunion de seguimiento Semanal |  | 1d | 2022-01-05 | 2022-01-05 | 79 | 2022-01-05 | 2022-01-05 | 1d | 0d |  | Gerente General (Arquitecta) [50%]; Maestro de Obra; Administrador; Abogado | 28h | 280,068 | 280,068 |
| 84 | 4.2.2.4 | Elaborar Acta de Avances |  | 1d | 2022-01-05 | 2022-01-05 | 79 | 2022-01-05 | 2022-01-05 | 1d | 16d | 0d | Gerente General (Arquitecta) [50%] | 4h | 55,804 | 55,804 |
| 85 | HITO 9 | Entregable Puesta en Marcha Finalizada | milestone | 0d | 2022-01-05 | 2022-01-05 | 81, 82, 83, 84 | 2022-01-05 | 2022-01-05 | 0d | 26d |  |  |  |  |  |
| 86 | 5 | **Aseguramiento del Servicio** |  | 26d | 2022-01-06 | 2022-02-10 |  | 2022-01-06 | 2022-02-10 | 26d | 0d |  |  | 588h | 5,611,964 | 5,611,964 |
| 87 | 5.1 | **Supervisión en sitio de trabajo** |  | 13d | 2022-01-06 | 2022-01-24 |  | 2022-01-06 | 2022-01-24 | 13d | 5d |  |  | 196h | 1,887,140 | 1,887,140 |
| 88 | 5.1.1 | **Inspecciones** |  | 13d | 2022-01-06 | 2022-01-24 |  | 2022-01-06 | 2022-01-24 | 13d | 5d |  |  | 196h | 1,887,140 | 1,887,140 |
| 89 | 5.1.1.1 | Revisar hallazgos y registros anteriores |  | 3d | 2022-01-06 | 2022-01-10 | 83 | 2022-01-06 | 2022-01-10 | 3d | 5d | 0d | Gerente General (Arquitecta) [50%]; Gestor de Calidad | 36h | 398,340 | 398,340 |
| 90 | 5.1.1.2 | Planificar la tarea |  | 2d | 2022-01-11 | 2022-01-12 | 89, 81 | 2022-01-11 | 2022-01-12 | 2d | 5d | 0d | Gerente General (Arquitecta) [50%]; Gestor de Calidad; Maestro de Obra; Ayudante de Obra | 56h | 493,464 | 493,464 |
| 91 | 5.1.1.3 | Documentar el desarrollo de la tarea |  | 2d | 2022-01-13 | 2022-01-14 | 90, 81 | 2022-01-13 | 2022-01-14 | 2d | 5d | 0d | Gerente General (Arquitecta) [50%]; Maestro de Obra | 24h | 252,232 | 252,232 |
| 92 | 5.1.1.4 | Identificar problemas subyacentes |  | 2d | 2022-01-17 | 2022-01-18 | 91 | 2022-01-17 | 2022-01-18 | 2d | 5d | 0d | Gestor de Calidad; Maestro de Obra | 32h | 294,576 | 294,576 |
| 93 | 5.1.1.5 | Informar a la alta dirección |  | 2d | 2022-01-19 | 2022-01-20 | 92, 91 | 2022-01-19 | 2022-01-20 | 2d | 5d | 0d | Gestor de Calidad; Maestro de Obra | 32h | 294,576 | 294,576 |
| 94 | 5.1.1.6 | Hacer recomendaciones |  | 2d | 2022-01-21 | 2022-01-24 | 93, 84, 91, 92 | 2022-01-21 | 2022-01-24 | 2d | 5d | 0d | Gestor de Calidad | 16h | 153,952 | 153,952 |
| 95 | HITO 10 | Actividad de Inspecciones Finalizada | milestone | 0d | 2022-01-24 | 2022-01-24 | 94 | 2022-01-24 | 2022-01-24 | 0d | 13d |  |  |  |  |  |
| 96 | 5.2 | **Auditoria Externa** |  | 18d | 2022-01-06 | 2022-01-31 |  | 2022-01-06 | 2022-01-31 | 18d | 0d |  |  | 284h | 2,616,468 | 2,616,468 |
| 97 | 5.2.1 | **Informe de Auditoría** |  | 8d | 2022-01-06 | 2022-01-17 |  | 2022-01-06 | 2022-01-17 | 8d | 10d |  |  | 56h | 594,768 | 594,768 |
| 98 | 5.2.1.1 | Preparar al equipo de trabajo |  | 2d | 2022-01-06 | 2022-01-07 | 83, 82 | 2022-01-06 | 2022-01-07 | 2d | 10d | 0d | Maestro de Obra | 16h | 140,624 | 140,624 |
| 99 | 5.2.1.2 | Asignar el Auditor |  | 3d | 2022-01-10 | 2022-01-12 | 98 | 2022-01-10 | 2022-01-12 | 3d | 10d | 0d | Gerente General (Arquitecta) [50%] | 12h | 167,412 | 167,412 |
| 100 | 5.2.1.3 | Desarrollo de la Auditoria |  | 1d | 2022-01-13 | 2022-01-13 | 99 | 2022-01-13 | 2022-01-13 | 1d | 10d | 0d | Gestor de Calidad; Gerente General (Arquitecta) [50%] | 12h | 132,780 | 132,780 |
| 101 | 5.2.1.4 | Preparar el informe |  | 2d | 2022-01-14 | 2022-01-17 | 100 | 2022-01-14 | 2022-01-17 | 2d | 10d |  | Gestor de Calidad | 16h | 153,952 | 153,952 |
| 102 | 5.2.2 | **Propuesta Plan de Mejoras** |  | 18d | 2022-01-06 | 2022-01-31 |  | 2022-01-06 | 2022-01-31 | 18d | 0d |  |  | 228h | 2,021,700 | 2,021,700 |
| 103 | 5.2.2.1 | Identificar la actividad a mejorar |  | 2d | 2022-01-06 | 2022-01-07 | 83 | 2022-01-06 | 2022-01-07 | 2d | 0d |  | Gestor de Calidad | 16h | 153,952 | 153,952 |
| 104 | 5.2.2.2 | Entender el desarrollo de la actividad |  | 2d | 2022-01-10 | 2022-01-11 | 103 | 2022-01-10 | 2022-01-11 | 2d | 0d |  | Maestro de Obra; Ayudante de Obra | 32h | 227,904 | 227,904 |
| 105 | 5.2.2.3 | Reformular la Actividad |  | 2d | 2022-01-12 | 2022-01-13 | 104 | 2022-01-12 | 2022-01-13 | 2d | 0d |  | Gestor de Calidad; Maestro de Obra | 32h | 294,576 | 294,576 |
| 106 | 5.2.2.4 | Elaborar el plan de mejora |  | 2d | 2022-01-14 | 2022-01-17 | 105 | 2022-01-14 | 2022-01-17 | 2d | 0d |  | Gestor de Calidad; Gerente General (Arquitecta) [50%] | 24h | 265,560 | 265,560 |
| 107 | 5.2.2.5 | Comunicar el plan de mejora |  | 2d | 2022-01-18 | 2022-01-19 | 106 | 2022-01-18 | 2022-01-19 | 2d | 0d |  | Gerente General (Arquitecta) [50%] | 8h | 111,608 | 111,608 |
| 108 | 5.2.2.6 | Ejecutar el plan de mejora |  | 5d | 2022-01-20 | 2022-01-26 | 107 | 2022-01-20 | 2022-01-26 | 5d | 0d |  | Maestro de Obra; Ayudante de Obra | 80h | 569,760 | 569,760 |
| 109 | 5.2.2.7 | Supervisar el desarrollo de la actividad con base en el plan de mejora |  | 3d | 2022-01-27 | 2022-01-31 | 108 | 2022-01-27 | 2022-01-31 | 3d | 0d |  | Gestor de Calidad; Gerente General (Arquitecta) [50%] | 36h | 398,340 | 398,340 |

| ID | WBS | Task | Type | Duration | Start | Finish | Predecessors | Baseline start | Baseline finish | Baseline duration | Total slack | Free slack | Resources | Work | Cost | Baseline cost |
| --- | --- | --- | --- | --- | --- | --- | --- | --- | --- | --- | --- | --- | --- | --- | --- | --- |
| 110 | 5.3 | **Area de Calidad** |  | 8d | 2022-02-01 | 2022-02-10 |  | 2022-02-01 | 2022-02-10 | 8d | 0d |  |  | 108h | 1,108,356 | 1,108,356 |
| 111 | 5.3.1 | **Informe de Desempeño** |  | 5d | 2022-02-01 | 2022-02-07 |  | 2022-02-01 | 2022-02-07 | 5d | 0d |  |  | 84h | 773,532 | 773,532 |
| 112 | 5.3.1.1 | Definir puntos a evaluar |  | 1d | 2022-02-01 | 2022-02-01 | 93, 94, 101, 109 | 2022-02-01 | 2022-02-01 | 1d | 0d |  | Gerente General (Arquitecta) [50%]; Maestro de Obra | 12h | 126,116 | 126,116 |
| 113 | 5.3.1.2 | Definir fecha y equipo de trabajo al que se va a evaluar |  | 2d | 2022-02-02 | 2022-02-03 | 112 | 2022-02-02 | 2022-02-03 | 2d | 0d |  | Gerente General (Arquitecta) [50%]; Maestro de Obra; Gestor de Calidad; Ayudante de Obra | 56h | 493,464 | 493,464 |
| 114 | 5.3.1.3 | Diligenciar el informe de Desempeño |  | 2d | 2022-02-04 | 2022-02-07 | 113 | 2022-02-04 | 2022-02-07 | 2d | 0d |  | Gestor de Calidad | 16h | 153,952 | 153,952 |
| 115 | 5.3.2 | **Encuestas de Satisfaccion del cliente** |  | 3d | 2022-02-08 | 2022-02-10 |  | 2022-02-08 | 2022-02-10 | 3d | 0d |  |  | 24h | 334,824 | 334,824 |
| 116 | 5.3.2.1 | Diligenciar la encuesta de satisfacción |  | 1d | 2022-02-08 | 2022-02-08 | 114 | 2022-02-08 | 2022-02-08 | 1d | 0d |  | Gerente General (Arquitecta) | 8h | 111,608 | 111,608 |
| 117 | 5.3.2.2 | Realizar Acta de Cierre |  | 1d | 2022-02-09 | 2022-02-09 | 116 | 2022-02-09 | 2022-02-09 | 1d | 0d |  | Gerente General (Arquitecta) | 8h | 111,608 | 111,608 |
| 118 | 5.3.2.3 | Realizar Informe Final | manual | 1d | 2022-02-10 | 2022-02-10 | 117 | 2022-02-10 | 2022-02-10 | 1d |  |  | Gerente General (Arquitecta) [50%] | 8h | 111,608 | 111,608 |
| 119 | 6 | **Gerencia de Proyecto** |  | 37d | 2021-11-04 | 2021-12-24 |  | 2021-11-04 | 2021-12-24 | 37d | 0d |  |  | 508h | 7,087,108 | 7,087,108 |
| 120 | 6.1 | **Inicio** |  | 5d | 2021-11-04 | 2021-11-10 |  | 2021-11-04 | 2021-11-10 | 5d | 0d |  |  | 20h | 279,020 | 279,020 |
| 121 | 6.1.1 | **Acta de constitución del Proyecto** |  | 2d | 2021-11-04 | 2021-11-05 |  | 2021-11-04 | 2021-11-05 | 2d | 0d |  |  | 8h | 111,608 | 111,608 |
| 122 | 6.1.1.1 | Realizar acta de constitución |  | 2d | 2021-11-04 | 2021-11-05 | 27 | 2021-11-04 | 2021-11-05 | 2d | 0d |  | Gerente General (Arquitecta) [50%] | 8h | 111,608 | 111,608 |
| 123 | 6.1.2 | **Matriz de Interesados** |  | 3d | 2021-11-08 | 2021-11-10 |  | 2021-11-08 | 2021-11-10 | 3d | 15d |  |  | 12h | 167,412 | 167,412 |
| 124 | 6.1.2.1 | Realizar matriz de interesados |  | 3d | 2021-11-08 | 2021-11-10 | 122 | 2021-11-08 | 2021-11-10 | 3d | 15d | 0d | Gerente General (Arquitecta) [50%] | 12h | 167,412 | 167,412 |
| 125 | 6.2 | **Planeación** |  | 23d | 2021-11-08 | 2021-12-08 |  | 2021-11-08 | 2021-12-08 | 23d | 0d |  |  | 432h | 6,026,832 | 6,026,832 |
| 126 | 6.2.1 | **Plan de Gestión de Interesados** |  | 5d | 2021-11-11 | 2021-11-17 |  | 2021-11-11 | 2021-11-17 | 5d | 15d |  |  | 32h | 446,432 | 446,432 |
| 127 | 6.2.1.1 | Identificar y categorizar a los interesados |  | 3d | 2021-11-11 | 2021-11-15 | 124 | 2021-11-11 | 2021-11-15 | 3d | 15d | 0d | Gerente General (Arquitecta) [50%] | 12h | 167,412 | 167,412 |
| 128 | 6.2.1.2 | Realizar Matriz dependencia influencia |  | 3d | 2021-11-11 | 2021-11-15 | 124 | 2021-11-11 | 2021-11-15 | 3d | 15d | 0d | Gerente General (Arquitecta) [50%] | 12h | 167,412 | 167,412 |
| 129 | 6.2.1.3 | Diligenciar Formato para la resolución de conflictos y gestión de expectativas |  | 2d | 2021-11-16 | 2021-11-17 | 128, 127 | 2021-11-16 | 2021-11-17 | 2d | 15d |  | Gerente General (Arquitecta) [50%] | 8h | 111,608 | 111,608 |
| 130 | 6.2.2 | **Plan de Gestión del Alcance** |  | 18d | 2021-11-08 | 2021-12-01 |  | 2021-11-08 | 2021-12-01 | 18d | 5d |  |  | 72h | 1,004,472 | 1,004,472 |
| 131 | 6.2.2.1 | Realizar el Acta de declaración del alcance |  | 3d | 2021-11-08 | 2021-11-10 | 122 | 2021-11-08 | 2021-11-10 | 3d | 5d | 0d | Gerente General (Arquitecta) [50%] | 12h | 167,412 | 167,412 |
| 132 | 6.2.2.2 | Realizar EDP |  | 3d | 2021-11-11 | 2021-11-15 | 131 | 2021-11-11 | 2021-11-15 | 3d | 5d | 0d | Gerente General (Arquitecta) [50%] | 12h | 167,412 | 167,412 |
| 133 | 6.2.2.3 | Elaborar el diccionario de la WBS |  | 2d | 2021-11-16 | 2021-11-17 | 132 | 2021-11-16 | 2021-11-17 | 2d | 5d | 0d | Gerente General (Arquitecta) [50%] | 8h | 111,608 | 111,608 |
| 134 | 6.2.2.4 | Definir la Línea base de alcance |  | 1d | 2021-11-18 | 2021-11-18 | 133 | 2021-11-18 | 2021-11-18 | 1d | 5d | 0d | Gerente General (Arquitecta) [50%] | 4h | 55,804 | 55,804 |
| 135 | 6.2.2.5 | Diligenciar el documento de los requisitos |  | 3d | 2021-11-19 | 2021-11-23 | 134 | 2021-11-19 | 2021-11-23 | 3d | 5d | 0d | Gerente General (Arquitecta) [50%] | 12h | 167,412 | 167,412 |
| 136 | 6.2.2.6 | Realizar la Matriz de trazabilidad de requisitos |  | 3d | 2021-11-24 | 2021-11-26 | 135 | 2021-11-24 | 2021-11-26 | 3d | 5d | 0d | Gerente General (Arquitecta) [50%] | 12h | 167,412 | 167,412 |
| 137 | 6.2.2.7 | Realizar el Acta de cierre de proyecto o Entregable |  | 3d | 2021-11-29 | 2021-12-01 | 136 | 2021-11-29 | 2021-12-01 | 3d | 5d |  | Gerente General (Arquitecta) [50%] | 12h | 167,412 | 167,412 |

| ID | WBS | Task | Duration | Start | Finish | Predecessors | Baseline start | Baseline finish | Baseline duration | Total slack | Free slack | Resources | Work | Cost | Baseline cost |
| --- | --- | --- | --- | --- | --- | --- | --- | --- | --- | --- | --- | --- | --- | --- | --- |
| 138 | 6.2.3 | **Plan de Gestión del Cronograma** | 9d | 2021-11-08 | 2021-11-18 |  | 2021-11-08 | 2021-11-18 | 9d | 14d |  |  | 36h | 502,236 | 502,236 |
| 139 | 6.2.3.1 | Realizar el listado de actividades con estimación de duraciones esperadas | 3d | 2021-11-08 | 2021-11-10 | 122 | 2021-11-08 | 2021-11-10 | 3d | 14d | 0d | Gerente General (Arquitecta) [50%] | 12h | 167,412 | 167,412 |
| 140 | 6.2.3.2 | Definir la línea base de tiempo | 1d | 2021-11-11 | 2021-11-11 | 139 | 2021-11-11 | 2021-11-11 | 1d | 14d | 0d | Gerente General (Arquitecta) [50%] | 4h | 55,804 | 55,804 |
| 141 | 6.2.3.3 | Realizar el Diagrama de Red | 2d | 2021-11-12 | 2021-11-15 | 140 | 2021-11-12 | 2021-11-15 | 2d | 14d | 0d | Gerente General (Arquitecta) [50%] | 8h | 111,608 | 111,608 |
| 142 | 6.2.3.4 | Realizar el Cronograma – Diagrama de Gantt | 2d | 2021-11-16 | 2021-11-17 | 141 | 2021-11-16 | 2021-11-17 | 2d | 14d | 0d | Gerente General (Arquitecta) [50%] | 8h | 111,608 | 111,608 |
| 143 | 6.2.3.5 | Establecer la nivelación de recursos y uso de recursos | 1d | 2021-11-18 | 2021-11-18 | 142 | 2021-11-18 | 2021-11-18 | 1d | 14d |  | Gerente General (Arquitecta) [50%] | 4h | 55,804 | 55,804 |
| 144 | 6.2.4 | **Plan de Gestión de Costos** | 12d | 2021-11-08 | 2021-11-23 |  | 2021-11-08 | 2021-11-23 | 12d | 11d |  |  | 48h | 669,648 | 669,648 |
| 145 | 6.2.4.1 | Definir la Línea base de costos | 1d | 2021-11-08 | 2021-11-08 | 122 | 2021-11-08 | 2021-11-08 | 1d | 11d | 0d | Gerente General (Arquitecta) [50%] | 4h | 55,804 | 55,804 |
| 146 | 6.2.4.2 | Elaborar el Presupuesto por actividades | 3d | 2021-11-09 | 2021-11-11 | 145 | 2021-11-09 | 2021-11-11 | 3d | 11d | 0d | Gerente General (Arquitecta) [50%] | 12h | 167,412 | 167,412 |
| 147 | 6.2.4.3 | Elaborar la Estructura de desagregación de recursos ReBS | 2d | 2021-11-12 | 2021-11-15 | 146 | 2021-11-12 | 2021-11-15 | 2d | 11d | 0d | Gerente General (Arquitecta) [50%] | 8h | 111,608 | 111,608 |
| 148 | 6.2.4.4 | Elaborar la Estructura de Desagregación de Costos CBS. | 2d | 2021-11-16 | 2021-11-17 | 147 | 2021-11-16 | 2021-11-17 | 2d | 11d | 0d | Gerente General (Arquitecta) [50%] | 8h | 111,608 | 111,608 |
| 149 | 6.2.4.5 | Definir Indicadores de medición de desempeño | 1d | 2021-11-18 | 2021-11-18 | 148 | 2021-11-18 | 2021-11-18 | 1d | 11d | 0d | Gerente General (Arquitecta) [50%] | 4h | 55,804 | 55,804 |
| 150 | 6.2.4.6 | Aplicar la técnica del valor ganado con curvas S avance | 3d | 2021-11-19 | 2021-11-23 | 149 | 2021-11-19 | 2021-11-23 | 3d | 11d |  | Gerente General (Arquitecta) [50%] | 12h | 167,412 | 167,412 |
| 151 | 6.2.5 | **Plan de Gestión de la Calidad** | 9d | 2021-11-08 | 2021-11-18 |  | 2021-11-08 | 2021-11-18 | 9d | 14d |  |  | 36h | 502,236 | 502,236 |
| 152 | 6.2.5.1 | Definir las Especificaciones técnicas de requerimientos | 2d | 2021-11-08 | 2021-11-09 | 122 | 2021-11-08 | 2021-11-09 | 2d | 14d | 0d | Gerente General (Arquitecta) [50%] | 8h | 111,608 | 111,608 |
| 153 | 6.2.5.2 | Definir la Herramienta de control de la calidad | 1d | 2021-11-10 | 2021-11-10 | 152 | 2021-11-10 | 2021-11-10 | 1d | 14d | 0d | Gerente General (Arquitecta) [50%] | 4h | 55,804 | 55,804 |
| 154 | 6.2.5.3 | Definir como se va a desarrollar el Formato de Inspecciones | 2d | 2021-11-11 | 2021-11-12 | 153 | 2021-11-11 | 2021-11-12 | 2d | 14d | 0d | Gerente General (Arquitecta) [50%] | 8h | 111,608 | 111,608 |
| 155 | 6.2.5.4 | Definir como se va a desarrollar el Formato de Auditorias | 2d | 2021-11-15 | 2021-11-16 | 154 | 2021-11-15 | 2021-11-16 | 2d | 14d | 0d | Gerente General (Arquitecta) [50%] | 8h | 111,608 | 111,608 |
| 156 | 6.2.5.5 | Definir las listas de verificación de los entregables | 2d | 2021-11-17 | 2021-11-18 | 155 | 2021-11-17 | 2021-11-18 | 2d | 14d |  | Gerente General (Arquitecta) [50%] | 8h | 111,608 | 111,608 |
| 157 | 6.2.6 | **Plan de Gestión de los Recursos** | 23d | 2021-11-08 | 2021-12-08 |  | 2021-11-08 | 2021-12-08 | 23d | 0d |  |  | 92h | 1,283,492 | 1,283,492 |
| 158 | 6.2.6.1 | Realizar laIdentificación y adquisición de recursos | 3d | 2021-11-08 | 2021-11-10 | 122 | 2021-11-08 | 2021-11-10 | 3d | 0d |  | Gerente General (Arquitecta) [50%] | 12h | 167,412 | 167,412 |
| 159 | 6.2.6.2 | Realizar la Estructura desagregación de recursos | 2d | 2021-11-11 | 2021-11-12 | 158 | 2021-11-11 | 2021-11-12 | 2d | 0d |  | Gerente General (Arquitecta) [50%] | 8h | 111,608 | 111,608 |
| 160 | 6.2.6.3 | Definir los Roles, Responsabilidades y Competencias del equipo | 2d | 2021-11-15 | 2021-11-16 | 159 | 2021-11-15 | 2021-11-16 | 2d | 0d |  | Gerente General (Arquitecta) [50%] | 8h | 111,608 | 111,608 |
| 161 | 6.2.6.4 | Diligenciar la Matriz de asignación de Responsabilidades | 3d | 2021-11-17 | 2021-11-19 | 160 | 2021-11-17 | 2021-11-19 | 3d | 0d |  | Gerente General (Arquitecta) [50%] | 12h | 167,412 | 167,412 |
| 162 | 6.2.6.5 | Realizar Histograma y horario de recursos | 3d | 2021-11-22 | 2021-11-24 | 161 | 2021-11-22 | 2021-11-24 | 3d | 0d |  | Gerente General (Arquitecta) [50%] | 12h | 167,412 | 167,412 |
| 163 | 6.2.6.6 | Elaborar el Plan de capacitación y desarrollo del equipo | 2d | 2021-11-25 | 2021-11-26 | 162 | 2021-11-25 | 2021-11-26 | 2d | 0d |  | Gerente General (Arquitecta) [50%] | 8h | 111,608 | 111,608 |
| 164 | 6.2.6.7 | Realizar la identificación de procesos de seguridad y salud en el trabajo | 2d | 2021-11-29 | 2021-11-30 | 163 | 2021-11-29 | 2021-11-30 | 2d | 0d |  | Gerente General (Arquitecta) [50%] | 8h | 111,608 | 111,608 |
| 165 | 6.2.6.8 | Elaborar el Esquema de contratación y liberación del personal | 2d | 2021-12-01 | 2021-12-02 | 164 | 2021-12-01 | 2021-12-02 | 2d | 0d |  | Gerente General (Arquitecta) [50%] | 8h | 111,608 | 111,608 |
| 166 | 6.2.6.9 | Definir los indicadores de medición de desempeño del equipo y esquema de incentivos y recompensas. | 2d | 2021-12-03 | 2021-12-06 | 165 | 2021-12-03 | 2021-12-06 | 2d | 0d |  | Gerente General (Arquitecta) [50%] | 8h | 111,608 | 111,608 |
| 167 | 6.2.6.10 | Identifcar las habilidades blandas para el desarrollo del proyecto. | 2d | 2021-12-07 | 2021-12-08 | 166 | 2021-12-07 | 2021-12-08 | 2d | 0d |  | Gerente General (Arquitecta) [50%] | 8h | 111,608 | 111,608 |

| ID | WBS | Task | Type | Duration | Start | Finish | Predecessors | Baseline start | Baseline finish | Baseline duration | Total slack | Free slack | Resources | Work | Cost | Baseline cost |
| --- | --- | --- | --- | --- | --- | --- | --- | --- | --- | --- | --- | --- | --- | --- | --- | --- |
| 168 | 6.2.7 | **Plan de Gestión de las Comunicaciones** |  | 6d | 2021-11-08 | 2021-11-15 |  | 2021-11-08 | 2021-11-15 | 6d | 17d |  |  | 24h | 334,824 | 334,824 |
| 169 | 6.2.7.1 | Diligenciar la Matriz de comunicaciones |  | 3d | 2021-11-08 | 2021-11-10 | 122 | 2021-11-08 | 2021-11-10 | 3d | 17d | 0d | Gerente General (Arquitecta) [50%] | 12h | 167,412 | 167,412 |
| 170 | 6.2.7.2 | Realizar el Flujograma de las comunicaciones |  | 2d | 2021-11-11 | 2021-11-12 | 169 | 2021-11-11 | 2021-11-12 | 2d | 17d | 0d | Gerente General (Arquitecta) [50%] | 8h | 111,608 | 111,608 |
| 171 | 6.2.7.3 | Realizar el Glosario de terminología común |  | 1d | 2021-11-15 | 2021-11-15 | 170 | 2021-11-15 | 2021-11-15 | 1d | 17d |  | Gerente General (Arquitecta) [50%] | 4h | 55,804 | 55,804 |
| 172 | 6.2.8 | **Plan de Gestión de los Riesgos** |  | 13d | 2021-11-08 | 2021-11-24 |  | 2021-11-08 | 2021-11-24 | 13d | 10d |  |  | 52h | 725,452 | 725,452 |
| 173 | 6.2.8.1 | Realizar la Identificación de riesgos y determinación de umbral |  | 3d | 2021-11-08 | 2021-11-10 | 122 | 2021-11-08 | 2021-11-10 | 3d | 10d | 0d | Gerente General (Arquitecta) [50%] | 12h | 167,412 | 167,412 |
| 174 | 6.2.8.2 | Elaborar la Risk Breakdown Structure -RiBS- |  | 3d | 2021-11-11 | 2021-11-15 | 173 | 2021-11-11 | 2021-11-15 | 3d | 10d | 0d | Gerente General (Arquitecta) [50%] | 12h | 167,412 | 167,412 |
| 175 | 6.2.8.3 | Elaborar el análisis de riesgos del proyecto (cualitativo y cuantitativo) |  | 2d | 2021-11-16 | 2021-11-17 | 174 | 2021-11-16 | 2021-11-17 | 2d | 10d | 0d | Gerente General (Arquitecta) [50%] | 8h | 111,608 | 111,608 |
| 176 | 6.2.8.4 | Diligenciar la Matriz de riesgos |  | 3d | 2021-11-18 | 2021-11-22 | 175 | 2021-11-18 | 2021-11-22 | 3d | 10d | 0d | Gerente General (Arquitecta) [50%] | 12h | 167,412 | 167,412 |
| 177 | 6.2.8.5 | Elaborar el Plan de respuesta a riesgo |  | 2d | 2021-11-23 | 2021-11-24 | 176 | 2021-11-23 | 2021-11-24 | 2d | 10d |  | Gerente General (Arquitecta) [50%] | 8h | 111,608 | 111,608 |
| 178 | 6.2.9 | **Plan de Gestión de Adquisiciones** |  | 10d | 2021-11-08 | 2021-11-19 |  | 2021-11-08 | 2021-11-19 | 10d | 13d |  |  | 40h | 558,040 | 558,040 |
| 179 | 6.2.9.1 | Definir los criterios de valoración de proveedores |  | 2d | 2021-11-08 | 2021-11-09 | 122 | 2021-11-08 | 2021-11-09 | 2d | 13d | 0d | Gerente General (Arquitecta) [50%] | 8h | 111,608 | 111,608 |
| 180 | 6.2.9.2 | Definir como es la selección y tipificación de contratos |  | 2d | 2021-11-10 | 2021-11-11 | 179 | 2021-11-10 | 2021-11-11 | 2d | 13d | 0d | Gerente General (Arquitecta) [50%] | 8h | 111,608 | 111,608 |
| 181 | 6.2.9.3 | Definir los criterios de contratación, ejecución y control de compras y contratos |  | 2d | 2021-11-12 | 2021-11-15 | 180 | 2021-11-12 | 2021-11-15 | 2d | 13d | 0d | Gerente General (Arquitecta) [50%] | 8h | 111,608 | 111,608 |
| 182 | 6.2.9.4 | Elaborar el cronograma de compras con la asignación de responsable |  | 2d | 2021-11-16 | 2021-11-17 | 181 | 2021-11-16 | 2021-11-17 | 2d | 13d | 0d | Gerente General (Arquitecta) [50%] | 8h | 111,608 | 111,608 |
| 183 | 6.2.9.5 | Definir la sostenibilidad en el proceso de adquisiciones |  | 2d | 2021-11-18 | 2021-11-19 | 182 | 2021-11-18 | 2021-11-19 | 2d | 13d |  | Gerente General (Arquitecta) [50%] | 8h | 111,608 | 111,608 |
| 184 | HITO 3 | Documentación de los planes de gestión Terminada | milestone | 0d | 2021-12-08 | 2021-12-08 | 129, 137, 143, 150, 156, 167, 171, 177, 183 | 2021-12-08 | 2021-12-08 | 0d | 34d | 0d |  |  |  |  |
| 185 | 6.3 | **Ejecución** |  | 2d | 2021-12-09 | 2021-12-10 |  | 2021-12-09 | 2021-12-10 | 2d | 34d |  |  | 8h | 111,608 | 111,608 |
| 186 | 6.3.1 | **Asignar tareas con base en Objetivos del Proyecto** |  | 2d | 2021-12-09 | 2021-12-10 |  | 2021-12-09 | 2021-12-10 | 2d | 34d |  |  | 8h | 111,608 | 111,608 |
| 187 | 6.3.1.1 | Lanzar el Proyecto |  | 2d | 2021-12-09 | 2021-12-10 | 184 | 2021-12-09 | 2021-12-10 | 2d | 34d | 0d | Gerente General (Arquitecta) [50%] | 8h | 111,608 | 111,608 |
| 188 | 6.4 | **Seguimiento y Control** |  | 2d | 2021-12-13 | 2021-12-14 |  | 2021-12-13 | 2021-12-14 | 2d | 34d |  |  | 16h | 223,216 | 223,216 |
| 189 | 6.4.1 | **Reunión de Seguimiento Semanal** |  | 1d | 2021-12-13 | 2021-12-13 |  | 2021-12-13 | 2021-12-13 | 1d | 34d |  |  | 4h | 55,804 | 55,804 |
| 190 | 6.4.1.1 | Realizar Reunion de avance del plan de gestion |  | 1d | 2021-12-13 | 2021-12-13 | 187 | 2021-12-13 | 2021-12-13 | 1d | 34d | 0d | Gerente General (Arquitecta) [50%] | 4h | 55,804 | 55,804 |
| 191 | 6.4.2 | **Informe de desempeño del Trabajo** |  | 2d | 2021-12-13 | 2021-12-14 |  | 2021-12-13 | 2021-12-14 | 2d | 35d |  |  | 12h | 167,412 | 167,412 |
| 192 | 6.4.2.1 | Definir puntos a evaluar del plan de gestion |  | 1d | 2021-12-13 | 2021-12-13 | 187 | 2021-12-13 | 2021-12-13 | 1d | 43d |  | Gerente General (Arquitecta) [50%] | 4h | 55,804 | 55,804 |
| 193 | 6.4.2.2 | Definir criterios o escala de evaluación |  | 1d | 2021-12-13 | 2021-12-13 | 187 | 2021-12-13 | 2021-12-13 | 1d | 43d |  | Gerente General (Arquitecta) [50%] | 4h | 55,804 | 55,804 |
| 194 | 6.4.2.3 | Elaborar informe de Desempeño |  | 1d | 2021-12-14 | 2021-12-14 | 190 | 2021-12-14 | 2021-12-14 | 1d | 34d | 0d | Gerente General (Arquitecta) [50%] | 4h | 55,804 | 55,804 |
| 195 | HITO 4 | Entregable de Ejecución Terminada | milestone | 0d | 2021-12-14 | 2021-12-14 | 194 | 2021-12-14 | 2021-12-14 | 0d | 34d | 0d |  |  |  |  |

| ID | WBS | Task | Duration | Start | Finish | Predecessors | Baseline start | Baseline finish | Baseline duration | Total slack | Free slack | Resources | Work | Cost | Baseline cost |
| --- | --- | --- | --- | --- | --- | --- | --- | --- | --- | --- | --- | --- | --- | --- | --- |
| 196 | 6.5 | **Cierre** | 8d | 2021-12-15 | 2021-12-24 |  | 2021-12-15 | 2021-12-24 | 8d | 34d |  |  | 32h | 446,432 | 446,432 |
| 197 | 6.5.1 | **Actas e Informes** | 6d | 2021-12-15 | 2021-12-22 |  | 2021-12-15 | 2021-12-22 | 6d | 34d |  |  | 24h | 334,824 | 334,824 |
| 198 | 6.5.1.1 | Realizar Acta de Cierre | 3d | 2021-12-15 | 2021-12-17 | 195 | 2021-12-15 | 2021-12-17 | 3d | 34d | 0d | Gerente General (Arquitecta) [50%] | 12h | 167,412 | 167,412 |
| 199 | 6.5.1.2 | Realizar Informe Final | 3d | 2021-12-20 | 2021-12-22 | 198 | 2021-12-20 | 2021-12-22 | 3d | 34d | 0d | Gerente General (Arquitecta) [50%] | 12h | 167,412 | 167,412 |
| 200 | 6.5.2 | **Lecciones aprendidas** | 2d | 2021-12-23 | 2021-12-24 |  | 2021-12-23 | 2021-12-24 | 2d | 34d |  |  | 8h | 111,608 | 111,608 |
| 201 | 6.5.2.1 | Documentar Lecciones Aprendidas | 2d | 2021-12-23 | 2021-12-24 | 199 | 2021-12-23 | 2021-12-24 | 2d | 34d |  | Gerente General (Arquitecta) [50%] | 8h | 111,608 | 111,608 |
